# geodetski radovi pri projektovanju i izradi gradskog parka u Kladovu

Schedule from MS Project, 2011-01-10 to 2011-01-27.

## Calendars

- Standard: Mon-Fri 08:00-12:00, 13:00-17:00; Sat-Sun off.

## Resources

| Resource | Group |
| --- | --- |
| bolcne | 26 |
| farba | 3 |
| kreda | 5 |
| papir | 100 |
| boja za štampače | 3 |
| totalna stanica 1 | 1 |
| totalna stanica 2 | 1 |
| nivelir 1 | 1 |
| geodeta 1 | 1 |
| geodeta 2 | 1 |
| figurant 1 | 1 |
| figurant 2 | 1 |
| računar 1 | 1 |
| softver | 1 |
| geodeta 3 | 1 |
| odgovorno lice-šef | 1 |

## Schedule

| ID | Task | Duration | Start | Finish | Predecessors | Total slack | Resources | Work |
| --- | --- | --- | --- | --- | --- | --- | --- | --- |
| 1 | pripremni radovi-organizacija | 1d | 2011-01-10 | 2011-01-10 |  | 0d | odgovorno lice-šef | 8h |
| 2 | saradnja sa projektantom, detalji, usklađivanja, potrebni podaci, dogovori | 0.5d | 2011-01-11 | 2011-01-11 | 1 | 2.5d | odgovorno lice-šef | 4h |
| 3 | prijava radova, podnošenje zahteva SKN za potrebne podatke (katastar nepokretnosti i katastar vodova), preuzimanje podataka | 0.5d | 2011-01-11 | 2011-01-11 | 1 | 2.5d | geodeta 3 | 4h |
| 4 | rekognisciranje lokalne geodetske mreže | 0.5d | 2011-01-11 | 2011-01-11 | 1 | 0d | geodeta 1; geodeta 2; figurant 1; figurant 2 | 16h |
| 5 | postavljanje i stabilizacija geodetskih tačaka lokalne mreže, snimanje, obrada podataka I izravnanje geodetske mreže | 1.5d | 2011-01-11 | 2011-01-12 | 4 | 0d | geodeta 1; geodeta 2; figurant 1; figurant 2; totalna stanica 1; bolcne; farba; kreda | 96h |
| 6 | snimanje detalja sa lokalne geodetske mreže | 1d | 2011-01-13 | 2011-01-13 | 5 | 0d | totalna stanica 1; totalna stanica 2; geodeta 1; geodeta 2; figurant 1; figurant 2 | 48h |
| 7 | transformacija koordinata u državni koordinatni sistem, obrada podataka, izrada katastarsko topografskog plana (nulto stanje), predaja projektantu | 2d | 2011-01-14 | 2011-01-17 | 3, 6, 2 | 0d | geodeta 1; geodeta 2; računar 1; softver; papir; boja za štampače | 96h |
| 8 | obeležavanje projektovane trase podzemnih instalacija | 1d | 2011-01-18 | 2011-01-18 | 7 | 0d | geodeta 2; figurant 2; totalna stanica 2 | 24h |
| 9 | projektovana nivelacija-prenošenje na teren podataka iz projekta za potrebe zemljanih radova | 2d | 2011-01-18 | 2011-01-19 | 7 | 0d | geodeta 1; figurant 1; totalna stanica 1 | 48h |
| 10 | obeležavanje lokaliteta za gejzire i šahte | 1d | 2011-01-19 | 2011-01-19 | 8 | 0d | geodeta 2; figurant 2; totalna stanica 2 | 24h |
| 11 | snimanje izvedenih podzemnih instalacija pre konačnog zatrpavanja | 1d | 2011-01-20 | 2011-01-20 | 10 | 0d | geodeta 2; figurant 2; totalna stanica 2; nivelir 1 | 32h |
| 12 | kontrola zemljanih radova, ponovna obeležavanja u cilju dobijanja projektovanih kota na terenu | 1d | 2011-01-20 | 2011-01-20 | 9 | 0d | geodeta 1; figurant 1; totalna stanica 1 | 24h |
| 13 | obeležavanje staza i ivičnjaka za staze, prenošenje na teren projektovanih kružnih krivina I klotoida | 1d | 2011-01-21 | 2011-01-21 | 11 | 0d | geodeta 2; figurant 2; totalna stanica 2 | 24h |
| 14 | obeležavanje mesta za postavljanje sadnica listopadnih I zimzelenih drveća | 2d | 2011-01-21 | 2011-01-24 | 12 | 0d | geodeta 1; figurant 1; totalna stanica 1 | 48h |
| 15 | obeležavanje sredine jezera koje je isušeno zbog čišćenja dna u cilju postavljanja opreme za gejzir I stabilizaciju opreme, kao I opreme za podvodno osvetljenje | 1d | 2011-01-25 | 2011-01-25 | 14 | 0d | geodeta 1; figurant 1; totalna stanica 1 | 24h |
| 16 | prenošenje na teren lokaliteta ostalih elemenata iz projekta (spomenici, predvišeni plato, predviđeni montažni objekat) | 2d | 2011-01-24 | 2011-01-25 | 13 | 0d | geodeta 2; figurant 2; totalna stanica 2 | 48h |
| 17 | snimanje izvedenog stanja parka | 2d | 2011-01-26 | 2011-01-27 | 15, 16 | 0d | geodeta 1; geodeta 2; figurant 1; figurant 2; totalna stanica 1; totalna stanica 2 | 96h |
