# Izvodjenje geodetskih radova za deonicu autoputa od 10 km

Schedule from MS Project, 2016-09-12 to 2017-05-09.

## Calendars

- Standard: Mon-Fri 08:00-12:00, 13:00-17:00; Sat-Sun off.

## Resources

| Resource |
| --- |
| Геодета |
| Фигурант |
| Тотална станица |
| Нивелир |
| Призма |
| Нивелманска летва |
| Нивелманска папуча |
| Рачунар |

## Schedule

| ID | Task | Duration | Start | Finish | Predecessors | Total slack | Constraint | Resources | Work |
| --- | --- | --- | --- | --- | --- | --- | --- | --- | --- |
| 1 | Обилазак терена и рекогносцирање терена | 1d | 2016-09-12 | 2016-09-12 |  | 0d | start no earlier than 2016-09-12 | Геодета [200%]; Фигурант [200%]; Рачунар | 25.87h |
| 2 | Снимање почетног стања ( пре скидања хумуса ) - Прва екипа | 6d | 2016-09-13 | 2016-09-20 | 1 | 0d | start no earlier than 2016-09-12 | Фигурант; Геодета; Призма; Тотална станица | 192h |
| 3 | Снимање почетног стања ( пре скидања хумуса ) - Друга екипа | 6d | 2016-09-13 | 2016-09-20 | 1 | 0d | start no earlier than 2016-09-12 | Геодета; Фигурант; Призма; Тотална станица | 192h |
| 4 | Обележавање трасе пута за скидање хумуса - Прва екипа | 4d | 2016-09-21 | 2016-09-26 | 2 | 0d |  | Геодета; Фигурант; Призма; Тотална станица; Рачунар | 160h |
| 5 | Обележавање трасе пута за скидање хумуса - Друга екипа | 4d | 2016-09-21 | 2016-09-26 | 3 | 0d |  | Геодета; Фигурант; Призма; Тотална станица; Рачунар | 160h |
| 6 | Снимање терена после скидања хумуса - Прва екипа | 5d | 2016-09-27 | 2016-10-03 | 4 | 0d |  | Геодета; Фигурант; Призма; Тотална станица | 160h |
| 7 | Снимање терена после скидања хумуса - Друга екипа | 5d | 2016-09-27 | 2016-10-03 | 5 | 0d |  | Геодета; Фигурант; Призма; Тотална станица | 160h |
| 8 | Обележавање ножица шкарпе усека и насипа - Прва екипа | 5d | 2016-10-04 | 2016-10-10 | 6 | 0d |  | Геодета; Фигурант; Призма; Тотална станица; Рачунар | 200h |
| 9 | Обележавање ножица шкарпе усека и насипа - Друга екипа | 5d | 2016-10-04 | 2016-10-10 | 7 | 0d |  | Геодета; Фигурант; Призма; Тотална станица; Рачунар | 200h |
| 10 | Праћење слојева усека и насипа - Прва екипа | 61d | 2016-10-11 | 2017-01-03 | 8 | 0d |  | Геодета; Фигурант; Призма; Тотална станица | 1952h |
| 11 | Обележавање висине слоја фракције 0-63 mm - Друга екипа | 20d | 2016-10-11 | 2016-11-07 | 9 | 0d |  | Геодета; Фигурант; Призма; Тотална станица; Рачунар | 800h |
| 12 | Обележавање висине слоја фракције 0-31,5 mm - Друга екипа | 21d | 2016-11-08 | 2016-12-06 | 11 | 0d |  | Геодета; Фигурант; Призма; Тотална станица; Рачунар | 840h |
| 13 | Обележавање ригола и канала за одводњавање - Друга екипа | 20d | 2016-12-07 | 2017-01-03 | 12 | 0d |  | Геодета; Фигурант; Призма; Тотална станица; Рачунар | 800h |
| 14 | Обележавање висине DNS асфалта - Прва екипа | 15d | 2017-01-04 | 2017-01-24 | 10 | 0d |  | Геодета; Фигурант; Нивелир; Нивелманска летва; Нивелманска папуча; Рачунар | 720h |
| 15 | Обележавање висине DNS асфалта - Друга екипа | 15d | 2017-01-04 | 2017-01-24 | 13 | 0d |  | Геодета; Фигурант; Нивелир; Нивелманска летва; Нивелманска папуча; Рачунар | 720h |
| 16 | Обележавање висине GNS асфалта - Прва екипа | 15d | 2017-01-25 | 2017-02-14 | 14 | 0d |  | Геодета; Фигурант; Нивелир; Нивелманска летва; Нивелманска папуча; Рачунар | 720h |
| 17 | Обележавање висине GNS асфалта - Друга екипа | 15d | 2017-01-25 | 2017-02-14 | 15 | 0d |  | Геодета; Фигурант; Нивелир; Нивелманска летва; Нивелманска папуча; Рачунар | 720h |
| 18 | Обележавање висине AB хабајућег слоја асфалта - Прва екипа | 15d | 2017-02-15 | 2017-03-07 | 16 | 0d |  | Геодета; Фигурант; Нивелир; Нивелманска летва; Нивелманска папуча; Рачунар | 720h |
| 19 | Обележавање висине AB хабајућег слоја асфалта - Друга екипа | 15d | 2017-02-15 | 2017-03-07 | 17 | 0d |  | Геодета; Фигурант; Нивелир; Нивелманска летва; Нивелманска папуча; Рачунар | 720h |
| 20 | Обележавање ограде - Прва екипа | 14d | 2017-03-08 | 2017-03-27 | 18 | 0d |  | Геодета; Фигурант; Тотална станица; Призма; Рачунар | 560h |
| 21 | Обележавање ограде - Друга екипа | 14d | 2017-03-08 | 2017-03-27 | 19 | 0d |  | Геодета; Фигурант; Тотална станица; Призма; Рачунар | 560h |
| 22 | Обележавање вертикалне сигнализације - Прва екипа | 8d | 2017-03-28 | 2017-04-06 | 20 | 0d |  | Геодета; Фигурант; Тотална станица; Призма; Рачунар | 320h |
| 23 | Обележавање вертикалне сигнализације - Друга екипа | 8d | 2017-03-28 | 2017-04-06 | 21 | 0d |  | Геодета; Фигурант; Тотална станица; Призма; Рачунар | 320h |
| 24 | Снимање изведеног стања ( положајно ) - Прва екипа | 10d | 2017-04-07 | 2017-04-20 | 22 | 0d |  | Геодета; Фигурант; Тотална станица; Призма | 320h |
| 25 | Снимање изведеног стања ( висинско ) - Друга екипа | 8d | 2017-04-07 | 2017-04-18 | 23 | 0d |  | Геодета; Фигурант; Нивелир; Нивелманска летва; Нивелманска папуча | 320h |
| 26 | Снимање изведеног стања ( висинско ) - Прва екипа | 8d | 2017-04-21 | 2017-05-02 | 24 | 0d |  | Геодета; Фигурант; Нивелманска летва; Нивелманска папуча | 256h |
| 27 | Снимање изведеног стања ( положајно ) - Друга екипа | 10d | 2017-04-19 | 2017-05-02 | 25 | 0d |  | Геодета; Фигурант; Тотална станица; Призма | 320h |
| 28 | Обрада података у бироу | 5d | 2017-05-03 | 2017-05-09 | 27, 26 | 0d |  | Геодета [200%]; Рачунар [200%] | 160h |
