# MREZNI PLAN SNIMANJA TERENA-7

Schedule from MS Project, 2010-12-09 to 2011-02-14.

## Calendars

- Standard: Mon-Fri 08:00-12:00, 13:00-17:00; Sat-Sun off.

## Resources

| Resource |
| --- |
| geometar |
| podnosilac zahteva |
| racunar |
| totalna stanica |
| figurant |

## Schedule

| ID | Task | Type | Duration | Start | Finish | Predecessors | Total slack | Resources | Work |
| --- | --- | --- | --- | --- | --- | --- | --- | --- | --- |
| 1 | Prijem zahteva za ponudu |  | 1d | 2010-12-09 | 2010-12-09 |  | 0d | geometar; podnosilac zahteva | 16h |
| 2 | Proučavanje projekta |  | 2d | 2010-12-10 | 2010-12-13 | 1 | 0d | geometar [200%] | 32h |
| 3 | Određivanje cene posla |  | 1d | 2010-12-14 | 2010-12-14 | 1, 2 | 0d | geometar [200%] | 16h |
| 4 | Ugovaranje posla |  | 2d | 2010-12-15 | 2010-12-16 | 2, 3 | 0d | geometar; podnosilac zahteva | 32h |
| 5 | prijava posla u katastru |  | 1d | 2010-12-17 | 2010-12-17 | 4 | 0d | geometar | 8h |
| 6 | narucivanje koordinata poligonske mreze |  | 1d | 2010-12-20 | 2010-12-20 | 5 | 1d | geometar | 8h |
| 7 | narucivanje katastarskog stanja |  | 2d | 2010-12-20 | 2010-12-21 | 5 | 0d | geometar | 16h |
| 8 | dobijanje podataka |  | 4d | 2010-12-22 | 2010-12-27 | 6, 7 | 0d |  |  |
| 9 | spremanje poligonske mreze za teren |  | 2d | 2010-12-22 | 2010-12-23 | 8SS | 3d | geometar; racunar | 16h |
| 10 | ubacivanje podataka u totalnu stanicu |  | 1d | 2010-12-28 | 2010-12-28 | 8 | 0d | geometar; totalna stanica | 16h |
| 11 | izlazak na teren | milestone | 0d | 2010-12-28 | 2010-12-28 | 9, 10 | 0d |  |  |
| 12 | trazenje tacaka poligonske mreze za snimanje |  | 1d | 2010-12-29 | 2010-12-29 | 11 | 0d | geometar | 8h |
| 13 | uzimanje orjentacije |  | 1d | 2010-12-29 | 2010-12-29 | 11 | 0d | geometar; totalna stanica; figurant | 24h |
| 14 | snimanje zadatog predmeta |  | 10d | 2010-12-30 | 2011-01-12 | 12, 13 | 0d | geometar [200%]; figurant; totalna stanica | 320h |
| 15 | izvlacenje podataka u računar |  | 1.5d | 2011-01-13 | 2011-01-14 | 14 | 0d | geometar; racunar; totalna stanica | 24h |
| 16 | obrada podataka |  | 14d | 2011-01-14 | 2011-02-03 | 15 | 6d | geometar [200%]; racunar | 224h |
| 17 | spremanje podataka za katastar |  | 20d | 2011-01-14 | 2011-02-11 | 15 | 0d | geometar; racunar | 160h |
| 18 | odnosenje podataka na overu |  | 1d | 2011-02-11 | 2011-02-14 | 16, 17 | 0d | geometar | 8h |
