# Mrezni plan Aleksandar Stojanovic s11-16

Schedule from MS Project, 2016-09-12 to 2016-10-28.

## Calendars

- Standard: Mon-Fri 08:00-12:00, 13:00-17:00; Sat-Sun off.

## Resources

| Resource |
| --- |
| Geometar |
| Figurant |
| Totalna stanica |
| Nivelir |
| GPS |
| Racunar |

## Schedule

| ID | Task | Type | Duration | Start | Finish | Predecessors | Total slack | Free slack | Constraint | Resources | Work |
| --- | --- | --- | --- | --- | --- | --- | --- | --- | --- | --- | --- |
| 1 | Rekognosciranje terena | manual | 1d | 2016-09-12 | 2016-09-12 |  |  |  |  | Geometar | 8h |
| 2 | Snimanje nultog stanja | manual | 4d | 2016-09-13 | 2016-09-16 | 1 |  |  |  | Geometar; Figurant; Totalna stanica | 96h |
| 3 | Nivelanje sina (nulto stanje) | manual | 4d | 2016-09-13 | 2016-09-16 | 1 |  |  |  | Geometar; Figurant; Nivelir | 96h |
| 4 | Obrada podataka u birou | manual | 1d | 2016-09-13 | 2016-09-13 | 1 |  |  |  | Geometar; Racunar | 16h |
| 5 | Snimanje I obelezavanje iskopa | manual | 1d | 2016-09-26 | 2016-09-26 | 3 |  |  |  | Geometar; Figurant; Totalna stanica | 24h |
| 6 | Snimanje I obelezavanje sljunka I tucanika | manual | 1d | 2016-09-27 | 2016-09-27 | 5 |  |  |  | Geometar; Figurant; Totalna stanica | 24h |
| 7 | Snimanje I obelezavanje iskopa |  | 1d | 2016-09-28 | 2016-09-28 | 3 | 63d | 0d | start no earlier than 2016-09-28 | Geometar; Figurant; Totalna stanica | 24h |
| 8 | Snimanje I obelezavanje sljunka I tucanika | manual | 1d | 2016-09-29 | 2016-09-29 | 7 |  |  |  | Geometar; Figurant; Totalna stanica | 24h |
| 9 | Snimanje I obelezavanje iskopa |  | 1d | 2016-09-30 | 2016-09-30 | 3 | 59d | 0d | start no earlier than 2016-09-30 | Geometar; Figurant; Totalna stanica | 24h |
| 10 | Snimanje I obelezavanje sljunka I tucanika | manual | 1d | 2016-10-03 | 2016-10-03 | 9 |  |  |  | Geometar; Figurant; Totalna stanica | 24h |
| 11 | Snimanje I obelezavanje iskopa | manual | 1d | 2016-10-04 | 2016-10-04 | 4 |  |  |  | Geometar; Figurant; Totalna stanica | 24h |
| 12 | Snimanje I obelezavanje sljunka I tucanika | manual | 1d | 2016-10-05 | 2016-10-05 | 11 |  |  |  | Geometar; Figurant; Totalna stanica | 24h |
| 13 | Snimanje I obelezavanje iskopa | manual | 1d | 2016-10-06 | 2016-10-06 | 12 |  |  |  | Geometar; Figurant; Totalna stanica | 24h |
| 14 | Snimanje I obelezavanje sljunka I tucanika | manual | 1d | 2016-10-07 | 2016-10-07 | 13 |  |  |  | Geometar; Figurant; Totalna stanica | 24h |
| 15 | Obelezavanje putnih prelaza | manual | 2d | 2016-10-10 | 2016-10-11 | 10 |  |  |  | Figurant; Geometar; Totalna stanica | 48h |
| 16 | Snimanje izvedenog stanja | manual | 4d | 2016-10-12 | 2016-10-17 | 14 |  |  |  | Geometar; Figurant; Totalna stanica | 96h |
| 17 | Nivelanje sina (izvedeno stanje) | manual | 4d | 2016-10-18 | 2016-10-21 | 16 |  |  |  | Geometar; Figurant; Nivelir | 96h |
| 18 | Obrada podataka u birou | manual | 5d | 2016-10-24 | 2016-10-28 |  |  |  |  | Geometar; Racunar | 80h |
